project bind10y4usability "BIND 10 year 4 usability work"  2012-05-01 +32w {
  # Set the default time zone for the project. If not specified, UTC
  # is used.
  timezone "UTC"
  # Hide the clock time. Only show the date.
  timeformat "%Y-%m-%d"
  # Use US format for numbers
  numberformat "-" "" "," "." 1
  # Pick a day during the project that will be reported as 'today' in
  # the project reports. If not specified, the current day will be
  # used, but this will likely be outside of the project range, so it
  # can't be seen in the reports.
  #now 2011-04-02
}

resource dnsteam "BIND 10 DNS Team" {
}

resource researcher "Resolver Researcher" {
    efficiency 0.25     # consider this to be 1 person, versus 4 on the team
}

# here we define our releases, and the sprints in each
task usability_r1 "Usability release 1" {
    task sprint20120515 "Sprint-20120515" {
        start 2012-05-01 
        end   2012-05-15
    }

    task sprint20120529 "Sprint-20120529" {
        start 2012-05-15 
        end   2012-05-29
    }

    task sprint20120612 "Sprint-20120515" {
        start 2012-05-29 
        end   2012-06-12
    }

    task sprint20120619 "Sprint-20120619 (hardening)" {
        start 2012-06-12 
        end   2012-06-19
        # allocate the team and set priority to maximum to block all
        # other work during the hardening sprint
        allocate dnsteam
        priority 1000
    }
}

task usability_r2 "Usability release 2" {
    task sprint20120703 "Sprint-20120703" {
        start 2012-06-19 
        end   2012-07-03
    }

    task sprint20120717 "Sprint-20120717" {
        start 2012-07-03 
        end   2012-07-17
    }

    task sprint20120731 "Sprint-20120731" {
        start 2012-07-17 
        end   2012-07-31
    }

    task sprint20120807 "Sprint-20120807 (hardening)" {
        start 2012-07-31 
        end   2012-08-07
        # allocate the team and set priority to maximum to block all
        # other work during the hardening sprint
        allocate dnsteam
        priority 1000
    }
}

task usability_r3 "Usability release 3" {
    task sprint20120821 "Sprint-20120821" {
        start 2012-08-07 
        end   2012-08-21
    }

    task sprint20120904 "Sprint-20120904" {
        start 2012-08-21 
        end   2012-09-04
    }

    task sprint20120918 "Sprint-20120918" {
        start 2012-09-04 
        end   2012-09-18
    }

    task sprint20120925 "Sprint-20120925 (hardening)" {
        start 2012-09-18 
        end   2012-09-25
        # allocate the team and set priority to maximum to block all
        # other work during the hardening sprint
        allocate dnsteam
        priority 1000
    }
}

task beta "Beta release" {
    start 2012-09-28 
}

# Here we list our high-level tasks, and point estimates.
# I've used 70 points per sprint, or 35 points per week, to convert
# our points into weeks. 

task nsec "NSEC" {
    # sponsor priority 1
    start 2012-05-01
    effort 0.95w        # 33 points
    priority 520
    allocate dnsteam
}

task ddns "DDNS" {
    # sponsor priority 3
    start 2012-05-15
    effort 1.63w        # 57 points
    priority 519
    allocate dnsteam
}

task nsid "Name server identifiers" {
    # sponsor priority 2
    start 2012-05-29
    effort 0.58w        # 20 points
    priority 518
    allocate dnsteam
}

task debug "Debugging aids (bind10-showtech, bug reporting, ...)" {
    # sponsor priority 4
    start 2012-06-19
    effort 0.72w         # 25 points
    priority 517
    allocate dnsteam
}

# http://tinyurl.com/6th5nca or 
# http://bind10.isc.org/query?status=accepted&status=assigned&status=new&status=reopened&status=reviewing&feature=~msgq&col=id&col=summary&col=status&col=type&col=priority&col=milestone&col=component&order=priority
task msgq "msgq++" {
    start 2012-05-01
    effort 2.86w        # 100 points
    allocate dnsteam
    priority 400
}

# here we change from full changes to only providing diffs
task config "Configuration improvements" {
    effort 2.43w        # 85 points
    allocate dnsteam
    depends msgq
}

# we have to de-prioritize statistics, and just get less work done
task stats "Statistics" {
    # sponsor priority 5
    effort 2.29w        # 80 points
    allocate dnsteam
    depends msgq
    depends config
    priority 550
}

task resolver "Resolver research" {
    # sponsor priority 6
    # NOTE: the resolver research had a wide range of estimates since 
    #       we aren't exactly sure what is involved... could be 90 points, 
    #       could be 200 points (!!)
#    effort 2.57w        # 90 points
#    effort 5.72w        # 200 points -> does not fit in time available!
    effort 3.86w        # 135 points
    allocate researcher
    start 2012-05-29    # just a guess, depends on Comcast
}

task xfrout "xfrout revamp" {
    # sponsor priority 7
    effort 1.43w        # 50 points
    allocate dnsteam
#    start 2012-08-21 
    depends msgq
}

task xfrin "xfrin & zonemgr revamp" {
    # sponsor priority 7
    effort 2.15w        # 75 points
    allocate dnsteam
#    start 2012-09-04 
    depends msgq
}

# we have to do less work on operational transparency
task transparency "Operational transparency" {
    # sponsor priority 8
    effort 2.75w        # 96 points (could go as high as 480!??!!)
    allocate dnsteam
}

task loading "Loading zones" {
    effort 2.15w        # 75 points
    allocate dnsteam
}

task datasrcscaling  "Data source scaling" {
    effort 2.58w        # 90 points, could also be 200 with shared-memory
    depends config
    allocate dnsteam
}

task logging "Logging improvements" {
    effort 1w        # 35 points
    allocate dnsteam
}

task bind9migration "BIND 9 migration" {
    effort 2w           # totally a guess!
    allocate dnsteam
}

task ui "User interface" {
    effort 3.5w         # just a guess!
    start 2012-06-11 
    allocate dnsteam
}

textreport frame "" {
  textreport index "Overview" {
    formats html
    center '<[report id="overview"]>'
  }
}


macro TaskTip [
  tooltip istask() -8<-
    '''Start: ''' <-query attribute='start'->
    '''End: ''' <-query attribute='end'->
    ----
    '''Resources:'''

    <-query attribute='resources'->
    ----
    '''Precursors: '''

    <-query attribute='precursors'->
    ----
    '''Followers: '''

    <-query attribute='followers'->
    ->8-
]

taskreport overview "" {
  columns name, start, end, effort, duration, chart { ${TaskTip} }
}

